# Week6_Part3

How a schedule from MS Project changed from version to version. A marks actual dates.

## Version 1 (data date 2012-06-03, saved 2013-02-26, file conveyor_belt_project_begin_part_3.mpp)

| ID | WBS | Task | Duration | Start | Finish | Predecessors | Total float |
| --- | --- | --- | --- | --- | --- | --- | --- |
| 1 | 1 | **Conveyor Belt Project** | 530d | 2010-01-04 | 2012-02-01 |  | 0d |
| 2 | 1.1 | **Hardware** | 440d | 2010-02-08 | 2011-10-28 |  | 0d |
| 3 |  | Hardware Specifications | 50d | 2010-02-08 | 2010-04-16 | 24 | 0d |
| 4 |  | Hardware Design | 70d | 2010-04-19 | 2010-07-27 | 3 | 0d |
| 5 |  | hardware documentation | 30d | 2010-07-28 | 2010-09-08 | 4 | 0d |
| 6 |  | prototypes | 80d | 2010-11-18 | 2011-03-15 | 25 | 50d |
| 7 |  | order circuit boards | 5d | 2011-06-30 | 2011-07-07 | 26 | 5d |
| 8 |  | assemble preproduction models | 30d | 2011-09-19 | 2011-10-28 | 7FS+50d | 5d |
| 9 | 1.2 | **operating systems** | 445d | 2010-02-08 | 2011-11-04 |  | 0d |
| 10 |  | kernel specifications | 20d | 2010-02-08 | 2010-03-05 | 24 | 30d |
| 11 | 1.2.2 | **drivers** | 310d | 2010-03-08 | 2011-05-24 |  | 0d |
| 12 |  | disk drivers | 100d | 2010-03-08 | 2010-07-27 | 10 | 30d |
| 13 |  | serial I/O drivers | 130d | 2010-11-18 | 2011-05-24 | 25 | 0d |
| 14 |  | memory management | 90d | 2010-03-08 | 2010-07-13 | 10 | 40d |
| 15 |  | operating system documentation | 25d | 2010-03-08 | 2010-04-09 | 10 | 105d |
| 16 |  | network interface | 90d | 2011-06-30 | 2011-11-04 | 26 | 0d |
| 17 | 1.3 | **utilities** | 415d | 2010-02-08 | 2011-09-23 |  | 30d |
| 18 |  | utilities specifications | 15d | 2010-02-08 | 2010-02-26 | 24 | 55d |
| 19 |  | routine utilities | 60d | 2010-03-01 | 2010-05-21 | 18 | 75d |
| 20 |  | complex utilities | 80d | 2010-03-01 | 2010-06-21 | 18 | 55d |
| 21 |  | utilities documentation | 20d | 2010-03-01 | 2010-03-26 | 18 | 115d |
| 22 |  | shell | 60d | 2011-06-30 | 2011-09-23 | 26 | 30d |
| 23 | 1.4 | **system integration** | 530d | 2010-01-04 | 2012-02-01 |  | 0d |
| 24 |  | architectural decisions | 25d | 2010-01-04 | 2010-02-05 |  | 0d |
| 25 |  | Integration first phase | 50d | 2010-09-09 | 2010-11-17 | 12, 15, 19, 20, 21, 5, 14 | 0d |
| 26 |  | system hard/software test | 25d | 2011-05-25 | 2011-06-29 | 6, 13 | 0d |
| 27 |  | project documentation | 50d | 2011-06-30 | 2011-09-09 | 26 | 40d |
| 28 |  | integration acceptance testing | 60d | 2011-11-07 | 2012-02-01 | 8, 16, 22, 27 | 0d |

## Version 2 (data date 2011-01-01, saved 2013-03-04, file cbp_part_5_pt.mpp)

Last finish 2012-02-01 → 2012-02-27 (+26d). Complete tasks 0 → 13.

Changed:

| ID | Task | Start | Finish | Duration | Complete | Total float | Other |
| --- | --- | --- | --- | --- | --- | --- | --- |
| 1 | **Conveyor Belt Project** | 2010-01-04 A | 2012-02-01 → 2012-02-27 (+26d) | 530d → 548d | 0% → 60% |  | baseline start none → 2010-01-04; baseline finish none → 2012-02-01 |
| 2 | **Hardware** | 2010-02-08 → 2010-02-09 A (+1d) | 2011-10-28 → 2011-11-23 (+26d) | 440d → 457d | 0% → 69% | 0d → 5d | resources development; Design → none; baseline start none → 2010-02-08; baseline finish none → 2011-10-28 |
| 3 | Hardware Specifications | 2010-02-08 → 2010-02-09 A (+1d) | 2010-04-16 → 2010-04-12 A (-4d) | 50d → 45d | 0% → 100% | 0d → none | resources development; Design → Design; Internal development; baseline start none → 2010-02-08; baseline finish none → 2010-04-16 |
| 4 | Hardware Design | 2010-04-19 → 2010-04-13 A (-6d) | 2010-07-27 → 2010-07-16 A (-11d) | 70d → 67d | 0% → 100% | 0d → none | baseline start none → 2010-04-19; baseline finish none → 2010-07-27 |
| 5 | hardware documentation | 2010-07-28 → 2010-07-19 A (-9d) | 2010-09-08 → 2010-08-24 A (-15d) | 30d → 27d | 0% → 100% | 0d → none | baseline start none → 2010-07-28; baseline finish none → 2010-09-08 |
| 6 | prototypes | 2010-11-18 → 2010-11-11 A (-7d) | 2011-03-15 → 2011-03-04 (-11d) | 80d → 78d | 0% → 44% | 50d → 75d | baseline start none → 2010-11-18; baseline finish none → 2011-03-15 |
| 7 | order circuit boards | 2011-06-30 → 2011-07-27 (+27d) | 2011-07-07 → 2011-08-02 (+26d) |  |  |  | baseline start none → 2011-06-30; baseline finish none → 2011-07-07 |
| 8 | assemble preproduction models | 2011-09-19 → 2011-10-13 (+24d) | 2011-10-28 → 2011-11-23 (+26d) |  |  |  | resources Assembly; development → Assembly; Internal development; baseline start none → 2011-09-19; baseline finish none → 2011-10-28 |
| 9 | **operating systems** | 2010-02-08 A | 2011-11-04 → 2011-12-01 (+27d) | 445d → 463d | 0% → 58% |  | baseline start none → 2010-03-09; baseline finish none → 2011-11-04 |
| 10 | kernel specifications | 2010-02-08 A | 2010-03-05 → 2010-03-12 A (+7d) | 20d → 25d | 0% → 100% | 30d → none | constraint none → start no earlier than 2010-02-08; baseline start none → 2010-03-09; baseline finish none → 2010-04-05 |
| 11 | **drivers** | 2010-03-08 → 2010-03-15 A (+7d) | 2011-05-24 → 2011-06-20 (+27d) | 310d → 323d | 0% → 55% |  | baseline start none → 2010-04-06; baseline finish none → 2011-05-24 |
| 12 | disk drivers | 2010-03-08 → 2010-03-15 A (+7d) | 2010-07-27 → 2010-08-17 A (+21d) | 100d → 110d | 0% → 100% | 30d → none | constraint none → finish no earlier than 2010-08-17; resources Assembly; development → Assembly; Internal development; baseline start none → 2010-04-06; baseline finish none → 2010-08-25 |
| 13 | serial I/O drivers | 2010-11-18 → 2010-11-11 A (-7d) | 2011-05-24 → 2011-06-20 (+27d) | 130d → 153d | 0% → 22% |  | resources development → Internal development; baseline start none → 2010-11-18; baseline finish none → 2011-05-24 |
| 14 | memory management | 2010-03-08 → 2010-03-15 A (+7d) | 2010-07-13 → 2010-07-30 A (+17d) | 90d → 98d | 0% → 100% | 40d → none | constraint none → finish no earlier than 2010-07-30; baseline start none → 2010-04-06; baseline finish none → 2010-08-11 |
| 15 | operating system documentation | 2010-03-08 → 2010-03-15 A (+7d) | 2010-04-09 → 2010-04-16 A (+7d) |  | 0% → 100% | 105d → none | baseline start none → 2010-04-06; baseline finish none → 2010-05-10 |
| 16 | network interface | 2011-06-30 → 2011-07-27 (+27d) | 2011-11-04 → 2011-12-01 (+27d) |  |  |  | resources development → Internal development; baseline start none → 2011-06-30; baseline finish none → 2011-11-04 |
| 17 | **utilities** | 2010-02-08 → 2010-03-01 A (+21d) | 2011-09-23 → 2011-10-19 (+26d) | 415d → 418d | 0% → 76% |  | baseline start none → 2010-02-08; baseline finish none → 2011-09-23 |
| 18 | utilities specifications | 2010-02-08 → 2010-03-08 A (+28d) | 2010-02-26 → 2010-03-29 A (+31d) | 15d → 16d | 0% → 100% | 55d → none | constraint none → finish no earlier than 2010-03-29; resources development; Design → Design; development; baseline start none → 2010-02-08; baseline finish none → 2010-02-26 |
| 19 | routine utilities | 2010-03-01 A | 2010-05-21 A |  | 0% → 100% | 75d → none | resources development → DevelopmentX; baseline start none → 2010-03-01; baseline finish none → 2010-05-21 |
| 20 | complex utilities | 2010-03-01 → 2010-03-30 A (+29d) | 2010-06-21 → 2010-08-11 A (+51d) | 80d → 95d | 0% → 100% | 55d → none | constraint none → finish no earlier than 2010-08-11; resources development → DevelopmentX; baseline start none → 2010-03-01; baseline finish none → 2010-06-21 |
| 21 | utilities documentation | 2010-03-01 → 2010-05-03 A (+63d) | 2010-03-26 → 2010-06-04 A (+70d) | 20d → 22d | 0% → 100% | 115d → none | baseline start none → 2010-03-01; baseline finish none → 2010-06-08 |
| 22 | shell | 2011-06-30 → 2011-07-27 (+27d) | 2011-09-23 → 2011-10-19 (+26d) |  |  |  | baseline start none → 2011-06-30; baseline finish none → 2011-09-23 |
| 23 | **system integration** | 2010-01-04 A | 2012-02-01 → 2012-02-27 (+26d) | 530d → 548d | 0% → 37% |  | baseline start none → 2010-01-04; baseline finish none → 2012-02-01 |
| 24 | architectural decisions | 2010-01-04 A | 2010-02-05 A |  | 0% → 100% | 0d → none | baseline start none → 2010-01-04; baseline finish none → 2010-02-05 |
| 25 | Integration first phase | 2010-09-09 → 2010-08-25 A (-15d) | 2010-11-17 → 2010-11-10 A (-7d) | 50d → 55d | 0% → 100% | 0d → none | constraint none → finish no earlier than 2010-11-10; baseline start none → 2010-09-09; baseline finish none → 2010-11-17 |
| 26 | system hard/software test | 2011-05-25 → 2011-06-21 (+27d) | 2011-06-29 → 2011-07-26 (+27d) |  |  |  | baseline start none → 2011-05-25; baseline finish none → 2011-06-29 |
| 27 | project documentation | 2011-06-30 → 2011-07-27 (+27d) | 2011-09-09 → 2011-10-05 (+26d) |  |  |  | baseline start none → 2011-06-30; baseline finish none → 2011-09-09 |
| 28 | integration acceptance testing | 2011-11-07 → 2011-12-02 (+25d) | 2012-02-01 → 2012-02-27 (+26d) |  |  |  | baseline start none → 2011-11-07; baseline finish none → 2012-02-01 |

## Version 3 (saved 2013-08-02, file conveyor_belt_project_1.mpp)

Last finish 2012-02-27 → 2011-12-28 (-61d). Complete tasks 13 → 0.

Added:

| ID | Task | Duration | Start | Finish | Predecessors | Resources |
| --- | --- | --- | --- | --- | --- | --- |
| 21 | Utilities Documentation | 20d | 2010-03-01 | 2010-03-29 | 18 | Documentation; Design |
| 22 | Shell | 60d | 2011-05-25 | 2011-08-19 | 26 | Development |
| 23 | **System Intergration** | 505d | 2010-01-04 | 2011-12-28 |  |  |
| 24 | Architectural Decisions | 25d | 2010-01-04 | 2010-02-08 |  | Design |
| 25 | Intergration First Phase | 50d | 2010-08-04 | 2010-10-14 | 12, 14, 15, 19, 20, 21, 5 | Assembly; Development |
| 26 | System Hard/Software Test | 25d | 2011-04-20 | 2011-05-25 | 6, 13 | Assembly |
| 27 | Project Documentation | 50d | 2011-05-25 | 2011-08-05 | 26 | Documentation; Development |
| 28 | Intergration Acceptance Testing | 60d | 2011-10-03 | 2011-12-28 | 16, 22, 27, 8 | Assembly; Development |

Removed: 5 hardware documentation; 6 prototypes; 7 order circuit boards; 8 assemble preproduction models; 9 operating systems; 10 kernel specifications; 11 drivers; 12 disk drivers

Changed:

| ID | Task | Start | Finish | Duration | Complete | Total float | Predecessors | Other |
| --- | --- | --- | --- | --- | --- | --- | --- | --- |
| 1 | **Compterized Conveyor Belt** | 2010-01-04 A → 2010-01-04 | 2012-02-27 → 2011-12-28 (-61d) | 548d → 505d | 60% → 0% | 0d → -390d |  | was named Conveyor Belt Project; baseline start 2010-01-04 → none; baseline finish 2012-02-01 → none |
| 2 | **Hardware** | 2010-02-09 A → 2010-01-04 (-36d) | 2011-11-23 → 2010-03-15 (-618d) | 457d → 50d | 69% → 0% | 5d → none | none → 24 | resources none → Development; Design; baseline start 2010-02-08 → none; baseline finish 2011-10-28 → none |
| 3 | Hardware Specifications | 2010-02-09 A → 2010-02-08 (-1d) | 2010-04-12 A → 2010-03-15 (-28d) | 45d → 25d | 100% → 0% | none → -390d | 16 → 24 | resources Design; Internal development → Design; Development; baseline start 2010-02-08 → none; baseline finish 2010-04-16 → none |
| 4 | Hardware Design | 2010-04-13 A → 2010-03-15 (-29d) | 2010-07-16 A → 2010-06-22 (-24d) | 67d → 70d | 100% → 0% | none → -390d |  | resources Design; development → Design; Development; baseline start 2010-04-19 → none; baseline finish 2010-07-27 → none |
| 5 | Hardware Documentation | 2010-11-11 A → 2010-06-22 (-142d) | 2011-06-20 → 2010-08-04 (-320d) | 153d → 30d | 22% → 0% | 0d → -390d | 17 → 4 | was named serial I/O drivers; resources Internal development → Documentation; Design; baseline start 2010-11-18 → none; baseline finish 2011-05-24 → none |
| 6 | Prototypes | 2010-03-15 A → 2010-10-14 (+213d) | 2010-07-30 A → 2011-02-09 (+194d) | 98d → 80d | 100% → 0% | none → -340d | kernel specifications → 25 | was named memory management; constraint finish no earlier than 2010-07-30 → none; resources development → Assembly; Development; baseline start 2010-04-06 → none; baseline finish 2010-08-11 → none |
| 7 | Order Circuit Boards | 2010-03-15 A → 2011-05-25 (+436d) | 2010-04-16 A → 2011-06-02 (+412d) | 25d → 5d | 100% → 0% | none → -390d | kernel specifications → 26 | was named operating system documentation; resources Design; documentation → Purchasing; baseline start 2010-04-06 → none; baseline finish 2010-05-10 → none |
| 8 | Assemble Pre Production Models | 2011-07-27 → 2011-08-12 (+16d) | 2011-12-01 → 2011-09-26 (-66d) | 90d → 30d |  | 0d → -390d | 18 → 7FS+50d | was named network interface; resources Internal development → Assembly; Development; baseline start 2011-06-30 → none; baseline finish 2011-11-04 → none |
| 9 | **Operating System** | 2010-03-01 A → 2010-02-08 (-21d) | 2011-10-19 → 2011-10-03 (-16d) | 418d → 420d | 76% → 0% | 30d → -385d |  | was named utilities; baseline start 2010-02-08 → none; baseline finish 2011-09-23 → none |
| 10 | Kernel Specifications | 2010-03-08 A → 2010-02-08 (-28d) | 2010-03-29 A → 2010-03-08 (-21d) | 16d → 20d | 100% → 0% | none → -385d | 16 → 24 | was named utilities specifications; constraint finish no earlier than 2010-03-29 → none; resources Design; development → Design; baseline start 2010-02-08 → none; baseline finish 2010-02-26 → none |
| 11 | **Drivers** | 2010-03-01 A → 2010-03-08 (+7d) | 2010-05-21 A → 2011-04-20 (+334d) | 60d → 285d | 100% → 0% | none → -390d | 10 → none | was named routine utilities; resources DevelopmentX → none; baseline start 2010-03-01 → none; baseline finish 2010-05-21 → none |
| 12 | Disk Drivers | 2010-03-30 A → 2010-03-08 (-22d) | 2010-08-11 A → 2010-07-28 (-14d) | 95d → 100d | 100% → 0% | none → -385d |  | was named complex utilities; constraint finish no earlier than 2010-08-11 → none; resources DevelopmentX → Assembly; Development; baseline start 2010-03-01 → none; baseline finish 2010-06-21 → none |
| 13 | Serial I/O Drivers | 2010-05-03 A → 2010-10-14 (+164d) | 2010-06-04 A → 2011-04-20 (+320d) | 22d → 130d | 100% → 0% | none → -390d | 10 → 25 | was named utilities documentation; resources documentation; Design → Development; baseline start 2010-03-01 → none; baseline finish 2010-06-08 → none |
| 14 | Memory Management | 2011-07-27 → 2010-03-08 (-506d) | 2011-10-19 → 2010-07-14 (-462d) | 60d → 90d |  | 30d → -375d | 18 → 10 | was named shell; resources development → Development; baseline start 2011-06-30 → none; baseline finish 2011-09-23 → none |
| 15 | Operating System Documentation | 2010-01-04 A → 2010-03-08 (+63d) | 2012-02-27 → 2010-04-12 (-686d) | 548d → 25d | 37% → 0% | 0d → -310d | none → 10 | was named system integration; resources none → Design; Documentation; baseline start 2010-01-04 → none; baseline finish 2012-02-01 → none |
| 16 | Network Interface | 2010-01-04 A → 2011-05-25 (+506d) | 2010-02-05 A → 2011-10-03 (+605d) | 25d → 90d | 100% → 0% | none → 0d | none → 26 | was named architectural decisions; resources Design → Development; baseline start 2010-01-04 → none; baseline finish 2010-02-05 → none |
| 17 | **Utilities** | 2010-08-25 A → 2010-02-08 (-198d) | 2010-11-10 A → 2011-08-19 (+282d) | 55d → 390d | 100% → 0% | none → -360d | disk drivers, 7, 11, 12, 13, hardware documentation, 6 → none | was named Integration first phase; constraint finish no earlier than 2010-11-10 → none; resources Assembly; development → none; baseline start 2010-09-09 → none; baseline finish 2010-11-17 → none |
| 18 | Utilities Specifications | 2011-06-21 → 2010-02-08 (-498d) | 2011-07-26 → 2010-03-01 (-512d) | 25d → 15d |  | 0d → -360d | prototypes, 5 → 24 | was named system hard/software test; resources Assembly → Development; Design; baseline start 2011-05-25 → none; baseline finish 2011-06-29 → none |
| 19 | Routine Utilities | 2011-07-27 → 2010-03-01 (-513d) | 2011-10-05 → 2010-05-24 (-499d) | 50d → 60d |  | 40d → -340d |  | was named project documentation; resources documentation; development → Development; baseline start 2011-06-30 → none; baseline finish 2011-09-09 → none |
| 20 | Complex Utilities | 2011-12-02 → 2010-03-01 (-641d) | 2012-02-27 → 2010-06-22 (-615d) | 60d → 80d |  | 0d → -360d | assemble preproduction models, 8, 14, 19 → 18 | was named integration acceptance testing; resources Assembly; development → Development; baseline start 2011-11-07 → none; baseline finish 2012-02-01 → none |

## Version 4 (data date 2010-10-01, saved 2013-08-18, file cbp_p5_q3_ms2007.mpp)

Last finish 2011-12-28 → 2012-01-19 (+22d). Complete tasks 0 → 12.

Added:

| ID | Task | Duration | Start | Finish | Predecessors | Resources |
| --- | --- | --- | --- | --- | --- | --- |
| 3 | Hardware specifications | 45d | 2010-02-09 A | 2010-04-12 A | 24 | Development; Design |
| 4 | Hardware design | 67d | 2010-04-13 A | 2010-07-16 A | 3 | Design; Development |
| 5 | Hardware documentation | 27d | 2010-07-19 A | 2010-08-24 A | 4 | Decumentation; Design |
| 7 | Order circuit boards | 5d | 2011-06-16 | 2011-06-22 | 26 | Purchasing |
| 8 | Assemble preproduction models | 30d | 2011-09-02 | 2011-10-14 | 7FS+50d | Assembly/test; Development |
| 9 | **Operating system** | 435d | 2010-02-08 A | 2011-10-21 |  |  |
| 10 | Kernel specifications | 25d | 2010-02-08 A | 2010-03-12 A | 24 | Design |
| 14 | Memory management | 98d | 2010-03-15 A | 2010-07-30 A | 10 | Development |
| 19 | Routine utilities | 65d | 2010-04-26 A | 2010-07-27 A | 18 | XDevelopment |
| 25 | Integration first phase | 50d | 2010-08-25 A | 2010-11-03 | 5, 12, 14, 15, 19, 20, 21 | Assembly/test; Development |

Removed: 3 Hardware Specifications; 9 Operating System; 14 Memory Management; 21 Utilities Documentation; 23 System Intergration; 24 Architectural Decisions; 25 Intergration First Phase; 26 System Hard/Software Test; 27 Project Documentation; 28 Intergration Acceptance Testing

Changed:

| ID | Task | Start | Finish | Duration | Complete | Total float | Predecessors | Other |
| --- | --- | --- | --- | --- | --- | --- | --- | --- |
| 1 | **Conveyor Belt Project** | 2010-01-04 A | 2011-12-28 → 2012-01-19 (+22d) | 505d → 520d | 0% → 54% | -390d → 0d |  | was named Compterized Conveyor Belt; baseline start none → 2010-01-04; baseline finish none → 2012-02-02 |
| 2 | **Hardware** | 2010-01-04 → 2010-02-09 A (+36d) | 2010-03-15 → 2011-10-14 (+578d) | 50d → 429d | 0% → 55% | none → 5d | Architectural Decisions → none | resources Development; Design → none; baseline start none → 2010-02-08; baseline finish none → 2011-10-28 |
| 6 | Prototypes | 2010-10-14 → 2010-11-04 (+21d) | 2011-02-09 → 2011-03-01 (+20d) |  |  | -340d → 50d | Intergration First Phase → 25 | resources Assembly; Development → Assembly/test; Development; baseline start none → 2010-11-18; baseline finish none → 2011-03-15 |
| 11 | **Drivers** | 2010-03-08 → 2010-03-15 A (+7d) | 2011-04-20 → 2011-05-10 (+20d) | 285d → 295d | 0% → 46% | -390d → 0d |  | baseline start none → 2010-03-08; baseline finish none → 2011-05-24 |
| 12 | Disk drivers | 2010-03-15 A | 2010-06-22 → 2010-08-17 A (+56d) | 70d → 110d | 0% → 100% | -390d → none | Hardware Specifications → 10 | was named Hardware Design; resources Design; Development → Assembly/test; Development; baseline start none → 2010-03-08; baseline finish none → 2010-07-27 |
| 13 | Serial I/O drivers | 2010-06-22 → 2010-11-04 (+135d) | 2010-08-04 → 2011-05-10 (+279d) | 30d → 130d |  | -390d → 0d | 12 → 25 | was named Hardware Documentation; resources Documentation; Design → Development; baseline start none → 2010-11-18; baseline finish none → 2011-05-24 |
| 15 | Operating system documentation | 2011-05-25 → 2010-03-15 A (-436d) | 2011-06-02 → 2010-04-16 A (-412d) | 5d → 25d | 0% → 100% | -390d → none | System Hard/Software Test → 10 | was named Order Circuit Boards; resources Purchasing → Design; Decumentation; baseline start none → 2010-03-29; baseline finish none → 2010-04-30 |
| 16 | Network interface | 2011-08-12 → 2011-06-16 (-57d) | 2011-09-26 → 2011-10-21 (+25d) | 30d → 90d |  | -390d → 0d | 15FS+50d → 26 | was named Assemble Pre Production Models; resources Assembly; Development → Development; baseline start none → 2011-06-30; baseline finish none → 2011-11-04 |
| 17 | **Utilities** | 2010-02-08 → 2010-03-08 A (+28d) | 2011-08-19 → 2011-09-09 (+21d) | 390d → 385d | 0% → 77% | -360d → 30d |  | baseline start none → 2010-03-08; baseline finish none → 2011-09-23 |
| 18 | Utilities specifications | 2010-02-08 → 2010-03-08 A (+28d) | 2010-03-08 → 2010-03-29 A (+21d) | 20d → 16d | 0% → 100% | -385d → none | Architectural Decisions → 24 | was named Kernel Specifications; resources Design → Development; Design; baseline start none → 2010-03-08; baseline finish none → 2010-03-26 |
| 20 | Complex utilities | 2010-03-08 → 2010-03-30 A (+22d) | 2010-07-28 → 2010-08-11 A (+14d) | 100d → 95d | 0% → 100% | -385d → none |  | was named Disk Drivers; resources Assembly; Development → Development; baseline start none → 2010-03-29; baseline finish none → 2010-07-20 |
| 21 | Utilities documentation | 2010-10-14 → 2010-05-03 A (-164d) | 2011-04-20 → 2010-06-02 A (-322d) | 130d → 22d | 0% → 100% | -390d → none | Intergration First Phase → 18 | was named Serial I/O Drivers; resources Development → Decumentation; Design; baseline start none → 2010-05-03; baseline finish none → 2010-05-28 |
| 22 | Shell | 2011-05-25 → 2011-06-16 (+22d) | 2011-08-19 → 2011-09-09 (+21d) |  |  |  | System Hard/Software Test → 26 | baseline start none → 2011-06-30; baseline finish none → 2011-09-23 |
| 23 | **System integration** | 2010-03-08 → 2010-01-04 A (-63d) | 2010-04-12 → 2012-01-19 (+647d) | 25d → 520d | 0% → 24% | -310d → 0d | 18 → none | was named Operating System Documentation; resources Design; Documentation → none; baseline start none → 2010-01-04; baseline finish none → 2012-02-02 |
| 24 | Architectural decisions | 2011-05-25 → 2010-01-04 A (-506d) | 2011-10-03 → 2010-02-05 A (-605d) | 90d → 25d | 0% → 100% | 0d → none | System Hard/Software Test → none | was named Network Interface; resources Development → Design; baseline start none → 2010-01-04; baseline finish none → 2010-02-05 |
| 26 | System hard/software test | 2010-02-08 → 2011-05-11 (+457d) | 2010-03-01 → 2011-06-15 (+471d) | 15d → 25d |  | -360d → 0d | Architectural Decisions → 6, 13 | was named Utilities Specifications; resources Development; Design → Assembly/test; baseline start none → 2011-05-25; baseline finish none → 2011-06-29 |
| 27 | Project documentation | 2010-03-01 → 2011-06-16 (+472d) | 2010-05-24 → 2011-08-25 (+458d) | 60d → 50d |  | -340d → 40d |  | was named Routine Utilities; resources Development → Decumentation; Development; baseline start none → 2011-06-30; baseline finish none → 2011-09-09 |
| 28 | Integration acceptance testing | 2010-03-01 → 2011-10-24 (+602d) | 2010-06-22 → 2012-01-19 (+576d) | 80d → 60d |  | -360d → 0d | 26 → 8, 16, 22, 27 | was named Complex Utilities; resources Development → Assembly/test; Development; baseline start none → 2011-11-07; baseline finish none → 2012-02-02 |

## Version 5 (data date 2011-01-01, saved 2013-08-18, file cbp_p5_q4_ms2003.mpp)

Last finish 2012-01-19 → 2012-02-28 (+40d). Complete tasks 12 → 13.

Changed:

| ID | Task | Start | Finish | Duration | Complete | Total float |
| --- | --- | --- | --- | --- | --- | --- |
| 1 | **Conveyor Belt Project** |  | 2012-01-19 → 2012-02-28 (+40d) | 520d → 548d | 54% → 61% |  |
| 2 | **Hardware** |  | 2011-10-14 → 2011-11-23 (+40d) | 429d → 457d | 55% → 69% |  |
| 6 | Prototypes | 2010-11-04 → 2010-11-11 A (+7d) | 2011-03-01 → 2011-03-04 (+3d) | 80d → 78d | 0% → 44% | 50d → 75d |
| 7 | Order circuit boards | 2011-06-16 → 2011-07-27 (+41d) | 2011-06-22 → 2011-08-02 (+41d) |  |  |  |
| 8 | Assemble preproduction models | 2011-09-02 → 2011-10-13 (+41d) | 2011-10-14 → 2011-11-23 (+40d) |  |  |  |
| 9 | **Operating system** |  | 2011-10-21 → 2011-12-01 (+41d) | 435d → 463d | 54% → 58% |  |
| 11 | **Drivers** |  | 2011-05-10 → 2011-06-20 (+41d) | 295d → 323d | 46% → 55% |  |
| 13 | Serial I/O drivers | 2010-11-04 → 2010-11-11 A (+7d) | 2011-05-10 → 2011-06-20 (+41d) | 130d → 153d | 0% → 22% |  |
| 16 | Network interface | 2011-06-16 → 2011-07-27 (+41d) | 2011-10-21 → 2011-12-01 (+41d) |  |  |  |
| 17 | **Utilities** |  | 2011-09-09 → 2011-10-19 (+40d) | 385d → 413d |  |  |
| 22 | Shell | 2011-06-16 → 2011-07-27 (+41d) | 2011-09-09 → 2011-10-19 (+40d) |  |  |  |
| 23 | **System integration** |  | 2012-01-19 → 2012-02-28 (+40d) | 520d → 548d | 24% → 37% |  |
| 25 | Integration first phase |  | 2010-11-03 → 2010-11-10 A (+7d) | 50d → 55d | 52% → 100% | 0d → none |
| 26 | System hard/software test | 2011-05-11 → 2011-06-21 (+41d) | 2011-06-15 → 2011-07-26 (+41d) |  |  |  |
| 27 | Project documentation | 2011-06-16 → 2011-07-27 (+41d) | 2011-08-25 → 2011-10-05 (+41d) |  |  |  |
| 28 | Integration acceptance testing | 2011-10-24 → 2011-12-02 (+39d) | 2012-01-19 → 2012-02-28 (+40d) |  |  |  |

## Version 6 (data date 2010-07-01, saved 2013-08-18, file cbp_p5_q2_ms2007.mpp)

Last finish 2012-02-28 → 2012-01-24 (-35d). Complete tasks 13 → 6.

Changed:

| ID | Task | Start | Finish | Duration | Complete | Total float |
| --- | --- | --- | --- | --- | --- | --- |
| 1 | **Conveyor Belt Project** |  | 2012-02-28 → 2012-01-24 (-35d) | 548d → 523d | 61% → 40% |  |
| 2 | **Hardware** |  | 2011-11-23 → 2011-10-19 (-35d) | 457d → 432d | 69% → 39% |  |
| 4 | Hardware design |  | 2010-07-16 A → 2010-07-16 |  | 100% → 84% | none → 0d |
| 5 | Hardware documentation | 2010-07-19 A → 2010-07-19 | 2010-08-24 A → 2010-08-27 (+3d) | 27d → 30d | 100% → 0% | none → 0d |
| 6 | Prototypes | 2010-11-11 A → 2010-11-09 (-2d) |  | 78d → 80d | 44% → 0% | 75d → 50d |
| 7 | Order circuit boards | 2011-07-27 → 2011-06-21 (-36d) | 2011-08-02 → 2011-06-27 (-36d) |  |  |  |
| 8 | Assemble preproduction models | 2011-10-13 → 2011-09-08 (-35d) | 2011-11-23 → 2011-10-19 (-35d) |  |  |  |
| 9 | **Operating system** |  | 2011-12-01 → 2011-10-26 (-36d) | 463d → 438d | 58% → 43% |  |
| 11 | **Drivers** |  | 2011-06-20 → 2011-05-13 (-38d) | 323d → 298d | 55% → 32% |  |
| 12 | Disk drivers |  | 2010-08-17 A → 2010-08-17 |  | 100% → 70% | none → 8d |
| 13 | Serial I/O drivers | 2010-11-11 A → 2010-11-09 (-2d) | 2011-06-20 → 2011-05-13 (-38d) | 153d → 130d | 22% → 0% |  |
| 14 | Memory management |  | 2010-07-30 A → 2010-07-28 (-2d) | 98d → 96d | 100% → 80% | none → 22d |
| 16 | Network interface | 2011-07-27 → 2011-06-21 (-36d) | 2011-12-01 → 2011-10-26 (-36d) |  |  |  |
| 17 | **Utilities** |  | 2011-10-19 → 2011-09-14 (-35d) | 413d → 388d | 77% → 59% |  |
| 19 | Routine utilities |  | 2010-07-27 A → 2010-07-27 |  | 100% → 72% | none → 23d |
| 20 | Complex utilities |  | 2010-08-11 A → 2010-08-05 (-6d) | 95d → 91d | 100% → 73% | none → 16d |
| 22 | Shell | 2011-07-27 → 2011-06-21 (-36d) | 2011-10-19 → 2011-09-14 (-35d) |  |  |  |
| 23 | **System integration** |  | 2012-02-28 → 2012-01-24 (-35d) | 548d → 523d | 37% → 12% |  |
| 25 | Integration first phase | 2010-08-25 A → 2010-08-30 (+5d) | 2010-11-10 A → 2010-11-08 (-2d) | 55d → 50d | 100% → 0% | none → 0d |
| 26 | System hard/software test | 2011-06-21 → 2011-05-16 (-36d) | 2011-07-26 → 2011-06-20 (-36d) |  |  |  |
| 27 | Project documentation | 2011-07-27 → 2011-06-21 (-36d) | 2011-10-05 → 2011-08-30 (-36d) |  |  |  |
| 28 | Integration acceptance testing | 2011-12-02 → 2011-10-27 (-36d) | 2012-02-28 → 2012-01-24 (-35d) |  |  |  |
