# CBP_2010_P3A_Outside_Slack

How a schedule from MS Project changed from version to version. A marks actual dates.

## Version 1 (data date 2010-04-01, saved 2007-05-22, file cbp_p5_q1_ms2007.mpp)

| ID | WBS | Task | Duration | Start | Finish | Predecessors | Complete | Total float |
| --- | --- | --- | --- | --- | --- | --- | --- | --- |
| 1 | 1 | **Conveyor Belt Project** | 526d | 2010-01-04 A | 2012-01-27 |  | 12% | 0d |
| 2 | 1.1 | **Hardware** | 435d | 2010-02-09 A | 2011-10-24 |  | 14% | 5d |
| 3 |  | Hardware specifications | 45d | 2010-02-09 A | 2010-04-12 | 24 | 82% | 0d |
| 4 |  | Hardware design | 70d | 2010-04-13 | 2010-07-21 | 3 |  | 0d |
| 5 |  | Hardware documentation | 30d | 2010-07-22 | 2010-09-01 | 4 |  | 0d |
| 6 |  | Prototypes | 80d | 2010-11-12 | 2011-03-09 | 25 |  | 50d |
| 7 |  | Order circuit boards | 5d | 2011-06-24 | 2011-06-30 | 26 |  | 5d |
| 8 |  | Assemble preproduction models | 30d | 2011-09-13 | 2011-10-24 | 7FS+50d |  | 5d |
| 9 | 1.2 | **Operating system** | 441d | 2010-02-08 A | 2011-10-31 |  | 14% | 0d |
| 10 |  | Kernel specifications | 25d | 2010-02-08 A | 2010-03-12 A | 24 | 100% |  |
| 11 | 1.2.2 | **Drivers** | 301d | 2010-03-15 A | 2011-05-18 |  | 6% | 0d |
| 12 |  | Disk drivers | 100d | 2010-03-15 A | 2010-08-03 | 10 | 13% | 21d |
| 13 |  | Serial I/O drivers | 130d | 2010-11-12 | 2011-05-18 | 25 |  | 0d |
| 14 |  | Memory management | 90d | 2010-03-15 A | 2010-07-20 | 10 | 14% | 31d |
| 15 |  | Operating system documentation | 20d | 2010-03-15 A | 2010-04-09 | 10 | 65% | 101d |
| 16 |  | Network interface | 90d | 2011-06-24 | 2011-10-31 | 26 |  | 0d |
| 17 | 1.3 | **Utilities** | 391d | 2010-03-08 A | 2011-09-19 |  | 7% | 30d |
| 18 |  | Utilities specifications | 16d | 2010-03-08 A | 2010-03-29 A | 24 | 100% |  |
| 19 |  | Routine utilities | 60d | 2010-03-30 | 2010-06-22 | 18 |  | 50d |
| 20 |  | Complex utilities | 87d | 2010-03-30 A | 2010-07-30 | 18 | 2% | 23d |
| 21 |  | Utilities documentation | 20d | 2010-05-04 | 2010-06-01 | 18 |  | 65d |
| 22 |  | Shell | 60d | 2011-06-24 | 2011-09-19 | 26 |  | 30d |
| 23 | 1.4 | **System integration** | 526d | 2010-01-04 A | 2012-01-27 |  | 12% | 0d |
| 24 |  | Architectural decisions | 25d | 2010-01-04 A | 2010-02-05 A |  | 100% |  |
| 25 |  | Integration first phase | 50d | 2010-09-02 | 2010-11-11 | 5, 12, 14, 15, 19, 20, 21 |  | 0d |
| 26 |  | System hard/software test | 25d | 2011-05-19 | 2011-06-23 | 6, 13 |  | 0d |
| 27 |  | Project documentation | 50d | 2011-06-24 | 2011-09-02 | 26 |  | 40d |
| 28 |  | Integration acceptance testing | 60d | 2011-11-01 | 2012-01-27 | 8, 16, 22, 27 |  | 0d |

## Version 2 (saved 2013-02-03, file conveyor_belt_project.mpp)

Last finish 2012-01-27 → 2011-12-28 (-30d). Complete tasks 3 → 0.

Added:

| ID | Task | Duration | Start | Finish | Predecessors | Resources |
| --- | --- | --- | --- | --- | --- | --- |
| 3 | Hardware Specifications | 25d | 2010-02-08 | 2010-03-15 | 24 | Design; Development |
| 9 | **Operating System** | 420d | 2010-02-08 | 2011-10-03 |  |  |
| 14 | Memory Management | 90d | 2010-03-08 | 2010-07-14 | 10 | Development |
| 21 | Utilities Documentation | 20d | 2010-03-01 | 2010-03-29 | 18 | Documentation; Design |
| 23 | **System Intergration** | 505d | 2010-01-04 | 2011-12-28 |  |  |
| 24 | Architectural Decisions | 25d | 2010-01-04 | 2010-02-08 |  | Design |
| 25 | Intergration First Phase | 50d | 2010-08-04 | 2010-10-14 | 12, 14, 15, 19, 20, 21, 5 | Assembly; Development |
| 26 | System Hard/Software Test | 25d | 2011-04-20 | 2011-05-25 | 6, 13 | Assembly |
| 27 | Project Documentation | 50d | 2011-05-25 | 2011-08-05 | 26 | Documentation; Development |
| 28 | Intergration Acceptance Testing | 60d | 2011-10-03 | 2011-12-28 | 16, 22, 27, 8 | Assembly; Development |

Removed: 3 Hardware specifications; 4 Hardware design; 5 Hardware documentation; 7 Order circuit boards; 8 Assemble preproduction models; 9 Operating system; 10 Kernel specifications; 14 Memory management; 19 Routine utilities; 25 Integration first phase

Changed:

| ID | Task | Start | Finish | Duration | Complete | Total float | Predecessors | Other |
| --- | --- | --- | --- | --- | --- | --- | --- | --- |
| 1 | **Compterized Conveyor Belt** | 2010-01-04 A → 2010-01-04 | 2012-01-27 → 2011-12-28 (-30d) | 526d → 505d | 12% → 0% | 0d → -390d |  | was named Conveyor Belt Project; baseline start 2010-01-04 → none; baseline finish 2012-02-02 → none |
| 2 | **Hardware** | 2010-02-09 A → 2010-01-04 (-36d) | 2011-10-24 → 2010-03-15 (-588d) | 435d → 50d | 14% → 0% | 5d → none | none → 24 | resources none → Development; Design; baseline start 2010-02-08 → none; baseline finish 2011-10-28 → none |
| 4 | Hardware Design | 2010-03-15 A → 2010-03-15 | 2010-08-03 → 2010-06-22 (-42d) | 100d → 70d | 13% → 0% | 21d → -390d | Kernel specifications → 3 | was named Disk drivers; resources Assembly/test; Development → Design; Development; baseline start 2010-03-08 → none; baseline finish 2010-07-27 → none |
| 5 | Hardware Documentation | 2010-11-12 → 2010-06-22 (-143d) | 2011-05-18 → 2010-08-04 (-287d) | 130d → 30d |  | 0d → -390d | Integration first phase → 4 | was named Serial I/O drivers; resources Development → Documentation; Design; baseline start 2010-11-18 → none; baseline finish 2011-05-24 → none |
| 6 | Prototypes | 2010-11-12 → 2010-10-14 (-29d) | 2011-03-09 → 2011-02-09 (-28d) |  |  | 50d → -340d | Integration first phase → 25 | resources Assembly/test; Development → Assembly; Development; baseline start 2010-11-18 → none; baseline finish 2011-03-15 → none |
| 7 | Order Circuit Boards | 2010-03-15 A → 2011-05-25 (+436d) | 2010-04-09 → 2011-06-02 (+419d) | 20d → 5d | 65% → 0% | 101d → -390d | Kernel specifications → 26 | was named Operating system documentation; resources Design; Decumentation → Purchasing; baseline start 2010-03-29 → none; baseline finish 2010-04-30 → none |
| 8 | Assemble Pre Production Models | 2011-06-24 → 2011-08-12 (+49d) | 2011-10-31 → 2011-09-26 (-35d) | 90d → 30d |  | 0d → -390d | 18 → 7FS+50d | was named Network interface; resources Development → Assembly; Development; baseline start 2011-06-30 → none; baseline finish 2011-11-04 → none |
| 10 | Kernel Specifications | 2010-03-08 A → 2010-02-08 (-28d) | 2010-03-29 A → 2010-03-08 (-21d) | 16d → 20d | 100% → 0% | none → -385d | 16 → 24 | was named Utilities specifications; resources Development; Design → Design; baseline start 2010-03-08 → none; baseline finish 2010-03-26 → none |
| 11 | **Drivers** | 2010-03-15 A → 2010-03-08 (-7d) | 2011-05-18 → 2011-04-20 (-28d) | 301d → 285d | 6% → 0% | 0d → -390d |  | baseline start 2010-03-08 → none; baseline finish 2011-05-24 → none |
| 12 | Disk Drivers | 2010-03-30 A → 2010-03-08 (-22d) | 2010-07-30 → 2010-07-28 (-2d) | 87d → 100d | 2% → 0% | 23d → -385d |  | was named Complex utilities; resources Development → Assembly; Development; baseline start 2010-03-29 → none; baseline finish 2010-07-20 → none |
| 13 | Serial I/O Drivers | 2010-05-04 → 2010-10-14 (+163d) | 2010-06-01 → 2011-04-20 (+323d) | 20d → 130d |  | 65d → -390d | 10 → 25 | was named Utilities documentation; resources Decumentation; Design → Development; baseline start 2010-05-03 → none; baseline finish 2010-05-28 → none |
| 15 | Operating System Documentation | 2010-01-04 A → 2010-03-08 (+63d) | 2012-01-27 → 2010-04-12 (-655d) | 526d → 25d | 12% → 0% | 0d → -310d | none → 10 | was named System integration; resources none → Design; Documentation; baseline start 2010-01-04 → none; baseline finish 2012-02-02 → none |
| 16 | Network Interface | 2010-01-04 A → 2011-05-25 (+506d) | 2010-02-05 A → 2011-10-03 (+605d) | 25d → 90d | 100% → 0% | none → 0d | none → 26 | was named Architectural decisions; resources Design → Development; baseline start 2010-01-04 → none; baseline finish 2010-02-05 → none |
| 17 | **Utilities** | 2010-03-08 A → 2010-02-08 (-28d) | 2011-09-19 → 2011-08-19 (-31d) | 391d → 390d | 7% → 0% | 30d → -360d |  | baseline start 2010-03-08 → none; baseline finish 2011-09-23 → none |
| 18 | Utilities Specifications | 2011-05-19 → 2010-02-08 (-465d) | 2011-06-23 → 2010-03-01 (-479d) | 25d → 15d |  | 0d → -360d | 6, 5 → 24 | was named System hard/software test; resources Assembly/test → Development; Design; baseline start 2011-05-25 → none; baseline finish 2011-06-29 → none |
| 19 | Routine Utilities | 2011-06-24 → 2010-03-01 (-480d) | 2011-09-02 → 2010-05-24 (-466d) | 50d → 60d |  | 40d → -340d |  | was named Project documentation; resources Decumentation; Development → Development; baseline start 2011-06-30 → none; baseline finish 2011-09-09 → none |
| 20 | Complex Utilities | 2011-11-01 → 2010-03-01 (-610d) | 2012-01-27 → 2010-06-22 (-584d) | 60d → 80d |  | 0d → -360d | Assemble preproduction models, 8, 22, 19 → 18 | was named Integration acceptance testing; resources Assembly/test; Development → Development; baseline start 2011-11-07 → none; baseline finish 2012-02-02 → none |
| 22 | Shell | 2011-06-24 → 2011-05-25 (-30d) | 2011-09-19 → 2011-08-19 (-31d) |  |  |  | 18 → 26 | baseline start 2011-06-30 → none; baseline finish 2011-09-23 → none |

## Version 3 (saved 2013-02-13, file conveyor_belt_project_part_two.mpp)

Last finish 2011-12-28 → 2012-01-23 (+26d).

Added:

| ID | Task | Duration | Start | Finish | Predecessors | Resources |
| --- | --- | --- | --- | --- | --- | --- |
| 1 | Begin Conveyor Belt Project | 0d | 2010-01-04 | 2010-01-04 |  |  |
| 2 | **System Integration** | 530d | 2010-01-04 | 2012-01-23 |  |  |
| 4 | Integration First Phase | 50d | 2010-09-09 | 2010-11-17 | 31, 32, 15, 23, 25, 26 | Assembly; Development |
| 5 | Integration Phase Complete | 0d | 2010-11-17 | 2010-11-17 | 4FF |  |
| 7 | System Test Complete | 0d | 2011-06-27 | 2011-06-27 | 6FF |  |
| 10 | Integrated Acceptance Testing | 60d | 2011-11-01 | 2012-01-23 | 8, 9, 18, 27 | Assembly; Development |
| 11 | Integrated Testing Complete | 0d | 2012-01-23 | 2012-01-23 | 10FF |  |
| 19 | Hardware Complete | 0d | 2011-10-24 | 2011-10-24 | 13FF, 14FF, 15FF, 16FF, 17FF, 18FF |  |
| 28 | Operating System Complete | 0d | 2011-10-31 | 2011-10-31 | 21FF, 23FF, 24FF, 25FF, 26FF, 27FF |  |
| 30 | Utilities Specification | 15d | 2010-02-08 | 2010-02-26 | 3 | Development; Design |
| 34 | Utilities Complete | 0d | 2010-06-21 | 2010-06-21 | 30FF, 31FF, 32FF, 33FF |  |
| 35 | Conveyor Belt Project Complete | 0d | 2012-01-23 | 2012-01-23 | 11FF, 19FF, 28FF, 34FF |  |

Removed: 1 Compterized Conveyor Belt; 8 Assemble Pre Production Models; 18 Utilities Specifications; 23 System Intergration; 28 Intergration Acceptance Testing

Changed:

| ID | Task | Start | Finish | Duration | Total float | Predecessors | Other |
| --- | --- | --- | --- | --- | --- | --- | --- |
| 3 | Architectural Decisions |  | 2010-02-08 → 2010-02-05 (-3d) |  | -390d → 0d | none → 1 |  |
| 6 | System Hard/Software Test | 2011-04-20 → 2011-05-24 (+34d) | 2011-05-25 → 2011-06-27 (+33d) |  | -390d → 0d |  |  |
| 8 | Shell | 2011-05-25 → 2011-06-28 (+34d) | 2011-08-19 → 2011-09-19 (+31d) |  |  | 6 → 7 |  |
| 9 | Project Documentation | 2011-05-25 → 2011-06-28 (+34d) | 2011-08-05 → 2011-09-05 (+31d) |  |  |  |  |
| 12 | **Hardware** | 2010-01-04 → 2010-02-08 (+35d) | 2010-03-15 → 2011-10-24 (+588d) | 50d → 440d | none → 0d | 3 → none | resources Development; Design → none |
| 13 | Hardware Specifications |  | 2010-03-15 → 2010-04-16 (+32d) | 25d → 50d | -390d → 0d |  | resources Design; Development → Development |
| 14 | Hardware Design | 2010-03-15 → 2010-04-19 (+35d) | 2010-06-22 → 2010-07-27 (+35d) |  | -390d → 0d |  | resources Design; Development → Development; Design |
| 15 | Hardware Documentation | 2010-06-22 → 2010-07-28 (+36d) | 2010-08-04 → 2010-09-08 (+35d) |  | -390d → 0d |  |  |
| 16 | Prototypes | 2010-10-14 → 2010-11-18 (+35d) | 2011-02-09 → 2011-03-14 (+33d) |  | -340d → 50d | 18 → 4 |  |
| 17 | Order Circuit Boards | 2011-05-25 → 2011-06-28 (+34d) | 2011-06-02 → 2011-07-04 (+32d) |  | -390d → 5d |  |  |
| 18 | Assemble Pre-Production Models | 2010-08-04 → 2011-09-13 (+405d) | 2010-10-14 → 2011-10-24 (+375d) | 50d → 30d | -390d → 5d | 23, 25, 26, 31, 32, 33, 15 → 17FS+50d | was named Intergration First Phase |
| 20 | **Operating System** |  | 2011-10-03 → 2011-10-31 (+28d) | 420d → 445d | -385d → 30d |  |  |
| 21 | Kernel Specifications |  | 2010-03-08 → 2010-03-05 (-3d) |  | -385d → 30d |  |  |
| 22 | **Drivers** |  | 2011-04-20 → 2011-05-23 (+33d) | 285d → 310d | -390d → 0d |  |  |
| 23 | Disk Drivers |  | 2010-07-28 → 2010-07-27 (-1d) |  | -385d → 30d |  |  |
| 24 | Serial I/O Drivers | 2010-10-14 → 2010-11-18 (+35d) | 2011-04-20 → 2011-05-23 (+33d) |  | -390d → 0d | 18 → 4 |  |
| 25 | Memory Management |  | 2010-07-14 → 2010-07-13 (-1d) |  | -375d → 40d |  |  |
| 26 | Operating System Documentation |  | 2010-04-12 → 2010-04-09 (-3d) |  | -310d → 105d |  |  |
| 27 | Network Interface | 2011-05-25 → 2011-06-28 (+34d) | 2011-10-03 → 2011-10-31 (+28d) |  |  |  |  |
| 29 | **Utilities** |  | 2011-08-19 → 2010-06-21 (-424d) | 390d → 95d | -360d → 55d |  |  |
| 31 | Routine Utilities |  | 2010-05-24 → 2010-05-21 (-3d) |  | -340d → 75d | Utilities Specifications → 30 |  |
| 32 | Complex Utilities |  | 2010-06-22 → 2010-06-21 (-1d) |  | -360d → 55d | Utilities Specifications → 30 |  |
| 33 | Utilities Documentation |  | 2010-03-29 → 2010-03-26 (-3d) |  | -300d → 470d | Utilities Specifications → 30 |  |
